# Projektplan mFund envVisio-GI

Schedule from GanttProject, 2020-09-14 to 2022-05-27.

## Calendars

- Project calendar: Mon-Fri working; Sat-Sun off.

## Resources

| Resource |
| --- |
| Fachhochschule Erfurt (FHE) |
| Kreis Lippe (LIP) |
| Stadt Leipzig (L) |
| Vogelsbergkreis (VK) |
| Stadt Dresden (DD) |
| Bundesamt für Kartographie und Geodäsie (BKG) |
| M.O.S.S. GmbH (MOSS) |
| Simplex4Data GmbH (S4D) |
| HRD Consulting (HRD) |
| Scopeland Technology GmbH (SCL) |

## Schedule

| ID | WBS | Task | Type | Duration | Start | Finish | Predecessors | Resources |
| --- | --- | --- | --- | --- | --- | --- | --- | --- |
| 1 | 1 | **Projektkoordination** |  | 191d | 2020-09-15 | 2021-06-08 |  |  |
| 2 | 1.1 | Regelmäßige Treffen der AG Anwendungsfall organisieren |  | 26d | 2020-09-15 | 2020-10-20 |  | Bundesamt für Kartographie und Geodäsie (BKG) |
| 3 | 1.2 | AG Anwendungsfall Treffen Termin | milestone | 0d | 2020-10-21 | 2020-10-21 | 2 | Fachhochschule Erfurt (FHE); Kreis Lippe (LIP); Stadt Leipzig (L); Vogelsbergkreis (VK); Stadt Dresden (DD); Bundesamt für Kartographie und Geodäsie (BKG); M.O.S.S. GmbH (MOSS); Simplex4Data GmbH (S4D); Scopeland Technology GmbH (SCL) |
| 4 | 1.3 | Gesamtprojekttreffen Terminfindung |  | 21d | 2020-12-01 | 2020-12-29 |  |  |
| 5 | 1.4 | **Unterarbeitspaketkoordination** |  | 135d | 2020-12-02 | 2021-06-08 |  |  |
| 6 | 1.4.1 | Gespräche zu AP2 (Datenimport) |  | 6d | 2020-12-02 | 2020-12-09 |  | Kreis Lippe (LIP); Stadt Leipzig (L); Vogelsbergkreis (VK); Stadt Dresden (DD); Bundesamt für Kartographie und Geodäsie (BKG); Simplex4Data GmbH (S4D); Scopeland Technology GmbH (SCL) |
| 7 | 1.4.2 | Gespräche zu AP5 (Services und APIs) |  | 6d | 2020-12-10 | 2020-12-17 |  | Bundesamt für Kartographie und Geodäsie (BKG); M.O.S.S. GmbH (MOSS) |
| 8 | 1.4.3 | Nicht Haupt-AP Aufgaben koordiniert | milestone | 0d | 2020-12-18 | 2020-12-18 | 6, 7 | Bundesamt für Kartographie und Geodäsie (BKG) |
| 9 | 1.4.4 | Gespräch zu 7.1 (Konzeption und Spezifikation) |  | 6d | 2020-12-18 | 2020-12-25 |  | Fachhochschule Erfurt (FHE); Kreis Lippe (LIP); Stadt Leipzig (L); Vogelsbergkreis (VK); Stadt Dresden (DD); Bundesamt für Kartographie und Geodäsie (BKG) |
| 10 | 1.4.5 | Gespräch zu 7.4 (Spezifikation des Datenmanagments) |  | 7d | 2020-12-25 | 2021-01-04 |  | Kreis Lippe (LIP); Stadt Leipzig (L); Vogelsbergkreis (VK); Stadt Dresden (DD); Bundesamt für Kartographie und Geodäsie (BKG); M.O.S.S. GmbH (MOSS); Simplex4Data GmbH (S4D) |
| 11 | 1.4.6 | Gespräch zu 7.5 (Implementierung von Anwendungsszenarien) |  | 6d | 2021-06-01 | 2021-06-08 |  | Bundesamt für Kartographie und Geodäsie (BKG); Scopeland Technology GmbH (SCL) |
| 12 | 2 | **AP7 (Anwendungsfall Klima und Mobilität)** |  | 122d | 2020-09-15 | 2021-03-03 |  |  |
| 13 | 2.1 | Präsentation über GDI Dokumente & Anforderungen |  | 1d | 2020-09-21 | 2020-09-21 |  | Bundesamt für Kartographie und Geodäsie (BKG) |
| 14 | 2.2 | Relevante GDI Dokumente den Projektpartnern bekannt | milestone | 0d | 2020-09-22 | 2020-09-22 | 13 |  |
| 15 | 2.3 | Erste Eruierungen der Anforderungen Anwendungsfall Klima&Mobilität |  | 26d | 2020-09-15 | 2020-10-20 |  |  |
| 16 | 2.4 | Bereich im GDI-DE Wiki zur Kommunikation und Organisation erstellt | milestone | 0d | 2020-10-20 | 2020-10-20 |  | Bundesamt für Kartographie und Geodäsie (BKG) |
| 17 | 2.5 | Dokumentation des Anwendungsfalls (Klima&Mobilität + inhaltlich&funktional) |  | 94d | 2020-10-20 | 2021-02-26 | 16 | Kreis Lippe (LIP); Stadt Leipzig (L); Vogelsbergkreis (VK); Stadt Dresden (DD); Bundesamt für Kartographie und Geodäsie (BKG) |
| 18 | 2.6 | Schärfung der Anforderungen |  | 29d | 2020-10-22 | 2020-12-01 | 15FS+1d | Kreis Lippe (LIP); Stadt Leipzig (L); Vogelsbergkreis (VK); Stadt Dresden (DD) |
| 19 | 2.7 | **Ausarbeitung der Anwendungsszenarien** |  | 24d | 2020-12-02 | 2021-01-04 | 18 |  |
| 20 | 2.7.1 | Fall: intelligentes/kommunenübergreifendes Verkehrsmanagment |  | 15d | 2020-12-15 | 2021-01-04 |  | Kreis Lippe (LIP) |
| 21 | 2.7.2 | Fall: Harmonisierung von Gebäudedaten |  | 12d | 2020-12-02 | 2020-12-17 |  | Vogelsbergkreis (VK) |
| 22 | 2.7.3 | Fall: Prozessoptimierung der Erstellung von Lärmkarten |  | 10d | 2020-12-10 | 2020-12-23 |  | Stadt Leipzig (L) |
| 23 | 2.7.4 | Fall: ? |  | 24d | 2020-12-02 | 2021-01-04 |  | Stadt Dresden (DD) |
| 24 | 2.8 | Erste ausgearbeitete Version von Anwendungsfällen der Projektpartner | milestone | 0d | 2021-01-05 | 2021-01-05 | 19 | Kreis Lippe (LIP); Stadt Leipzig (L); Vogelsbergkreis (VK); Stadt Dresden (DD) |
| 25 | 2.9 | UAP 7.3 (Datenbereitstellung und Visualisierung) |  | 42d | 2021-01-05 | 2021-03-03 | 24 | Fachhochschule Erfurt (FHE); Kreis Lippe (LIP); Stadt Leipzig (L); Vogelsbergkreis (VK); Stadt Dresden (DD); Bundesamt für Kartographie und Geodäsie (BKG) |
| 26 | 2.10 | Formulierung SMARTer Szenarien |  | 21d | 2021-01-05 | 2021-02-02 |  | Fachhochschule Erfurt (FHE); Kreis Lippe (LIP); Stadt Leipzig (L); Vogelsbergkreis (VK); Stadt Dresden (DD); Bundesamt für Kartographie und Geodäsie (BKG) |
| 27 | 2.11 | Konsolidierte Fassung der Anwendungsfälle | milestone | 0d | 2021-02-03 | 2021-02-03 | 26 |  |

Notes:
- 2: UAP 1.1 Projektkoordination
- 3: Jeden ersten Dienstag im Monat um 13:00 Uhr. / Infos zu den Teilnehmern im Ressourcentab.
- 4: UAP 1.1 Projektkoordination / Terminfindung für ein Treffen mit allen beteiligten Projektpartnern. / Informationsautasch innerhalb des Projekts zu zäh.
- 6: Terminfindung und anschließende Klärung welche Aufgaben das BKG bei / UAP 2.1 (Datenmapping und Modellanpassungen) und / UAP 2.2 (Ausführen der Datenimporte) hat.
- 7: Terminfindung und anschließende Klärung welche Aufgaben das BKG bei / UAP 5.1 (Entwicklung von Web Diensten für den Datenabruf) hat.
- 8: Alle Aufgaben, die nicht in den betreuten Arbeitspaketen 7 & 8 liegen wurden geklärt bzw. abgeschlossen.
- 9: - Erstellen der Sichten für INSPIRE, Berichte, Fachauskünfte und andere Datenbereitstellungen / - Erstellen der Sichten für den Anwendungsfall Klima und Mobilität / Was ist mit den Arbeitsschritten gemeint?
- 10: Terminfindung und anschließende Klärung welche Aufgaben das BKG bei / UAP 7.4 (Spezifikation des Datenmanagments) hat.
- 11: Ist Hilfe seitens des BKGs zu diesem Punkt notwendig?
- 14: Die Projektpartner bekennen sich dazu, Standards und Vorgaben der GDI-DE und INSPIRE einzuhalten. / Relevante Dokumente unter (UAP 7.1): / https://wiki.gdi-de.org/pages/viewpage.action?pageId=757764338
- 15: Erste Inputs: / - Vogelsbergkreis: Harmonisierung von Gebäudedaten / - Leipzig: Prozessoptimierung der Erstellung von Lärmkarten ( Harmonisierung der erforderlichen Daten und Verschneidung/Erzeugung) / - Lippe: inteligentes / Kommunenübergreifendes Verkehrsmanagement ... / - Dresden: noch offen. Bereitstellung von POI Informationen ...
- 16: Offener Bereich im GDI-DE Wiki für alle Projektpartner zugänglich (1 Zugang pro Partner) / Für jedes AP sind bereits eigene Seiten eingerichtet. / Für Datenbedarfe und bereits bekannte Quellen ist unter AP7 eine Tabelle hinterlegt: / https://wiki.gdi-de.org/pages/viewpage.action?pageId=760643802 / hier sollen Bedarfe und bereits bekannte Quellen durch alle Projektpartner ergänzt werden.
- 17: Die Dokumentation findet im GDI-DE Wiki statt und soll sich an der Dokumentation der Fachnetzwerke/technischer Umsetzung orientieren. / Um eine Nachnutzung zu gewährleisten ist eine umfangreiche Dokumentation (auch der Arbeitsschritte) notwendig. Dokumentation muss abstrahierbar sein (7.2).
- 18: Bereitgestellte Strukturen im GDI-DE Wiki sollen genutzt werden um Fälle zu diskutieren und auszuarbeiten.
- 19: Bis zum AG Anwendungsfall Treffen am 05.01.2021 sollen erste konkretere Anwendungsfälle der Projektpartner formuliert sein.
- 24: Sobald jeder kommunale Partner einen Anwendungsfall formuliert hat, kann damit begonnen werden, SMARTe Ziele für diese zu stecken.
- 25: UAP 7.3: Anforderungen für Datenbereitstellung (gemäß INSPIRE und GDI-DE) sowie an die Visualisierung der Ergebnisse (Technik und Dokumentation) müssen vertieft werden. / Diese werden dokumentiert. / Welche Vorstellungen haben die kommunalen Partner? / Was ist mit der Technik möglich? / --> Gespräche mit Technik und Kommunen
- 26: inkl. Gespräche mit Technik ob realisierbar / S – Spezifisch / M – Messbar / A – Akzeptiert / R – Realistisch / T – Terminierbar
- 27: UAP 7.2

| ID | WBS | Task | Type | Duration | Start | Finish | Predecessors | Resources |
| --- | --- | --- | --- | --- | --- | --- | --- | --- |
| 28 | 3 | **AP8 (Qualitätssicherung und Verwertung)** |  | 286d | 2021-02-03 | 2022-03-09 | 27 | Bundesamt für Kartographie und Geodäsie (BKG) |
| 29 | 3.1 | Erstellung Qualitätsplan |  | 19d | 2021-02-03 | 2021-03-01 |  |  |
| 30 | 3.2 | Qualitätskonzept erarbeitet | milestone | 0d | 2021-03-02 | 2021-03-02 | 29 |  |
| 31 | 3.3 | Überprüfung der Dokumentation |  | 89d | 2021-03-01 | 2021-07-01 | 17 |  |
| 32 | 3.4 | Dokumente zur Nachnutzung stehen bereit | milestone | 0d | 2021-07-02 | 2021-07-02 | 31 |  |
| 33 | 3.5 | Überprüfung der Datanbank auf Anforderungen der GDI-DE und Projektpartner |  | 66d | 2021-06-02 | 2021-09-01 | 38, 40 |  |
| 34 | 3.6 | Überprüfung der importierten Daten |  | 72d | 2021-03-01 | 2021-06-08 | 39 |  |
| 35 | 3.7 | Überprüfung der Anwendung |  | 154d | 2021-07-01 | 2022-02-01 | 41SS |  |
| 36 | 3.8 | Vergleich der finalen Anwendung mit SMART-Zielen |  | 6d | 2022-03-02 | 2022-03-09 | 42 |  |
| 37 | 4 | **Technische Vorgänge** |  | 382d | 2020-09-14 | 2022-03-01 |  |  |
| 38 | 4.1 | AP2 (Datenimport) |  | 187d | 2020-09-14 | 2021-06-01 |  | HRD Consulting (HRD) |
| 39 | 4.2 | Erste Datensichtungen | milestone | 0d | 2021-03-01 | 2021-03-01 |  |  |
| 40 | 4.3 | Zentrale Datenbank mit allen benötigten Daten | milestone | 0d | 2021-06-02 | 2021-06-02 | 38 |  |
| 41 | 4.4 | UAP 7.5 (Implementierung von Anwendungsszenarien) |  | 104d | 2021-06-09 | 2021-11-01 | 11 |  |
| 42 | 4.5 | Anwendungen sind Betriebsbereit | milestone | 0d | 2022-03-02 | 2022-03-02 | 35, 41 |  |
| 43 | 5 | **Hackathon** |  | 64d | 2022-03-01 | 2022-05-27 |  | Fachhochschule Erfurt (FHE); Bundesamt für Kartographie und Geodäsie (BKG) |
| 44 | 5.1 | Organisation Hackathon |  | 62d | 2022-03-01 | 2022-05-25 |  |  |
| 45 | 5.2 | Hackathon Durchführung |  | 2d | 2022-05-26 | 2022-05-27 | 44 |  |

Notes:
- 29: Sinnvolle Testszenarios für die Anwendungsfälle bestimmen
- 34: Werkzeuge: / - INSPIRE Validator / - Testsuite
- 35: Benutzung von GIS um Anwendungen/Daten/Dienste zu testen.
- 36: Relative Qualität des erreichten Zustands zu vorformulierten Zielen.
- 39: laut Rudolf
- 43: Wenn ein Hackathon bereits Mitte 2021 gewünscht/möglich ist uU Absprache mit F.Würriehausen zwecks Synergien. / 1. Projektleitung / 2. Falk
- 44: Hackathon soll zum Abschluss des Projektes stattfinden. / Verwendet werden im Optimalfall, Daten und Dienste die durch das envVisio-GI Projekt erarbeitet werden konnten.
